# SR-222 North (Widening)

Schedule from MS Project, 2022-09-23 to 2024-09-03.

## Calendars

- Standard: Mon-Fri 08:00-12:00, 13:00-17:00; Sat-Sun off. Exceptions (off unless hours are given): 2021-01-01 to 2040-01-01 (New Year's Day, recurring), 2022-01-17 to 2041-01-21 (MLK Day, recurring), 2022-02-21 to 2041-02-18 (Presidents Day, recurring), 2022-04-15 to 2041-04-19 (Good Friday, recurring), 2022-05-30 to 2041-05-27 (Memorial Day, recurring), 2022-07-04 to 2041-07-04 (Independence Day, recurring), 2022-09-05 to 2041-09-02 (Labor Day, recurring), 2022-11-11 to 2041-11-08 (Veterans Day, recurring), 2022-11-24 to 2041-11-28 (Thanksgiving, recurring), 2022-11-25 to 2041-11-22 (Day after Thanksgiving, recurring), 2022-12-24 to 2041-12-24 (Christmas Eve, recurring), 2022-12-25 to 2041-12-22 (Christmas , recurring), 2022-12-31 to 2041-12-31 (New Year's Eve, recurring).

## Resources

| Resource |
| --- |
| Kniazewycz |
| Cantrell |

## Schedule

| ID | WBS | Task | Duration | Start | Finish | Predecessors | Total slack | Free slack |
| --- | --- | --- | --- | --- | --- | --- | --- | --- |
| 1 | 1 | **STAGE 0 - PLANNING** | 111d? | 2022-09-26 | 2023-03-06 |  | 54d |  |
| 2 | 1.1 | **0SD1 Initiate Concept Report and Request Funding** | 30d | 2022-09-26 | 2022-11-04 |  | 54d |  |
| 3 | 1.1.1 | 1.0 Request and Finalize Safety Data | 15d | 2022-10-03 | 2022-10-21 | 4 | 69d | 5d |
| 4 | 1.1.2 | 2.0 Request Project Number, PIN, and Task Profile Numbers | 5d | 2022-09-26 | 2022-09-30 |  | 54d | 0d |
| 5 | 1.1.3 | 3.0 Coordinate with Long Range Planning | 5d | 2022-10-03 | 2022-10-07 | 4 | 473d | 15d |
| 6 | 1.1.4 | 4.0 Request and Finalize Traffic Data | 20d | 2022-10-03 | 2022-10-28 | 4 | 64d | 0d |
| 7 | 1.1.5 | 5.0 Request Preliminary Survey Data | 5d | 2022-10-03 | 2022-10-07 | 4 | 54d | 0d |
| 8 | 1.1.6 | 6.0 Initiate Division Reviews | 5d | 2022-10-31 | 2022-11-04 | 3, 5, 6, 7 | 458d |  |
| 9 | 1.2 | **0SD2 Develop Draft Concept Report** | 55d | 2022-10-31 | 2023-01-19 |  | 64d |  |
| 10 | 1.2.1 | 1.0 Conduct Intersection and Interchange Evaluation (IIE) (and traffic analysis) | 25d | 2022-10-31 | 2022-12-07 | 6, 3 | 438d |  |
| 11 | 1.2.2 | 2.0 Complete Conceptual Signal Warrants | 15d | 2022-10-31 | 2022-11-21 | 6 | 403d | 0d |
| 12 | 1.2.3 | 3.0 Develop Draft Conceptual Layouts/Crash Figures for Site Visit | 15d | 2022-11-15 | 2022-12-07 | 3, 6, 7, 33 | 54d | 0d |
| 13 | 1.2.4 | 4.0 Compile Initial Divisional Reviews for Site Visit | 10d | 2022-12-22 | 2023-01-04 | 42, 46, 36, 39 | 54d | 0d |
| 14 | 1.2.5 | 5.0 Prepare Site Visit Packet and Lead Site Visit | 5d | 2023-01-05 | 2023-01-11 | 13, 12 | 383d | 0d |
| 15 | 1.2.6 | 6.0 Initiate IAR Concept Coordination with FHWA | 30d | 2022-12-08 | 2023-01-19 | 6, 12 | 408d |  |
| 16 | 1.2.7 | 7.0 Develop, Compile, and Distribute the Draft Concept Report | 5d | 2023-01-12 | 2023-01-19 | 12, 3, 6, 14 | 383d | 0d |
| 17 | 1.3 | **0SD3 Finalize Concept Report** | 111d? | 2022-09-26 | 2023-03-06 |  | 377d |  |
| 18 | 1.3.1 | 1.0 Prepare Initial Risk Assessment | 1d? | 2022-09-26 | 2022-09-26 |  | 487d |  |
| 19 | 1.3.2 | 2.0 Finalize Conceptual Layouts | 10d | 2023-01-30 | 2023-02-10 | 12, 56, 55, 50, 44, 52, 16 | 377d | 0d |
| 20 | 1.3.3 | 3.0 Develop Environmental Technical Study Area (ETSA) | 10d | 2022-09-26 | 2022-10-07 |  | 463d | 86d |
| 21 | 1.3.4 | 4.0 Address Comments and Finalize the Concept Report | 10d | 2023-02-13 | 2023-02-27 | 19, 20, 59, 60 | 377d | 0d |
| 22 | 1.3.5 | 5.0 Request for Concept Report Signature(s) and Distribution | 5d | 2023-02-28 | 2023-03-06 | 21 | 377d |  |
| 23 | 1.3.6 | 6.0 Develop RSA No Plans Document | 1d | 2022-09-26 | 2022-09-26 |  | 487d |  |
| 24 | 1.4 | **0SD4 Develop State Industrial Access (SIA) Packet** | 20d? | 2022-09-26 | 2022-10-21 |  | 468d |  |
| 25 | 1.4.1 | 1.0 Receive Draft Application or Initial Request | 1d? | 2022-09-26 | 2022-09-26 |  | 487d |  |
| 26 | 1.4.2 | 2.0 Lead Site Visit | 1d? | 2022-09-26 | 2022-09-26 |  | 487d |  |
| 27 | 1.4.3 | 3.0 Develop Conceptual Layout, Cost Estimate, and Environmental Technical Study Area (ETSA) | 10d | 2022-09-26 | 2022-10-07 |  | 478d |  |
| 28 | 1.4.4 | 4.0 Conduct Benefit-Cost Analysis | 20d | 2022-09-26 | 2022-10-21 |  | 468d |  |
| 29 | 1.4.5 | 5.0 Develop Letter(s) of Approval | 5d | 2022-09-26 | 2022-09-30 |  | 483d |  |
| 30 | 1.4.6 | 6.0 Finalize the SIA Packet | 1d | 2022-09-26 | 2022-09-26 |  | 487d |  |

Notes:
- 4: If using the schedule that includes Stage 0, set your schedule off of this activity.
- 10: And complete needed traffic analysis (25 days total for both items)
- 18: Best practice to have this around the time of the site reviews or could be done during the site review
- 23: If needed, tie up accordingly
- 24: If applicable for SIA projects; tie up accordingly

| ID | WBS | Task | Duration | Start | Finish | Predecessors | Total slack | Free slack |
| --- | --- | --- | --- | --- | --- | --- | --- | --- |
| 31 | 1.5 | **0SY1 Provide Preliminary Survey Data** | 30d | 2022-10-10 | 2022-11-21 |  | 54d |  |
| 32 | 1.5.1 | 1.0 Set Control Ground Survey | 5d | 2022-10-10 | 2022-10-14 | 7 | 54d | 0d |
| 33 | 1.5.2 | 2.0 Provide Preliminary Survey Data | 20d | 2022-10-17 | 2022-11-14 | 32 | 54d | 0d |
| 34 | 1.5.3 | 3.0 Determine Time to Complete the Aerial Survey | 5d | 2022-11-15 | 2022-11-21 | 33 | 448d |  |
| 35 | 1.6 | **0EN1 Conduct Environmental Desktop Review** | 66d | 2022-10-03 | 2023-01-05 |  | 99d |  |
| 36 | 1.6.1 | 1.0 Identify Known Environmental Resource Information | 10d | 2022-10-03 | 2022-10-14 | 4 | 99d | 45d |
| 37 | 1.6.2 | 2.0 Attend Site Visit | 1d | 2023-01-05 | 2023-01-05 | 13 | 417d |  |
| 38 | 1.7 | **0GT1 Conduct Preliminary Geotechnical Assessment** | 66d | 2022-10-03 | 2023-01-05 |  | 99d |  |
| 39 | 1.7.1 | 1.0 Complete Geotechnical Division Review | 10d | 2022-10-03 | 2022-10-14 | 4 | 99d | 45d |
| 40 | 1.7.2 | 2.0 Attend Site Visit | 1d | 2023-01-05 | 2023-01-05 | 13 | 417d |  |
| 41 | 1.8 | **0MM1 Conduct Multimodal Review** | 36d | 2022-12-08 | 2023-01-27 |  | 54d |  |
| 42 | 1.8.1 | 1.0 Conduct Multimodal Review | 10d | 2022-12-08 | 2022-12-21 | 12 | 54d | 0d |
| 43 | 1.8.2 | 2.0 Attend Site Visit | 1d | 2023-01-05 | 2023-01-05 | 13 | 54d | 0d |
| 44 | 1.8.3 | 3.0 Develop Multimodal Considerations & Recommendations | 15d | 2023-01-06 | 2023-01-27 | 42, 43 | 54d | 0d |
| 45 | 1.9 | **0TO1 Conduct Initial Traffic Ops/TSMO Review** | 65d | 2022-10-31 | 2023-02-02 |  | 79d |  |
| 46 | 1.9.1 | 1.0 TSMO Alignment & Operations Review | 10d | 2022-10-31 | 2022-11-14 | 4, 6 | 79d | 25d |
| 47 | 1.9.2 | 2.0 Attend Site Visit | 1d | 2023-01-05 | 2023-01-05 | 13 | 417d |  |
| 48 | 1.9.3 | 3.0 Review the Concept Report | 10d | 2023-01-20 | 2023-02-02 | 16 | 398d |  |
| 49 | 1.10 | **0TO2 Develop TSMO Scope Items** | 65d | 2022-09-26 | 2022-12-28 |  | 423d |  |
| 50 | 1.10.1 | 1.0 Analyze Signal Warrants | 20d | 2022-11-22 | 2022-12-21 | 11, 6 | 403d | 0d |
| 51 | 1.10.2 | 2.0 Analyze Lighting Warrants | 5d | 2022-11-22 | 2022-11-30 | 11 | 438d | 15d |
| 52 | 1.10.3 | 3.0 Prepare TSMO & ITS Scope and Budget | 10d | 2022-09-26 | 2022-10-07 |  | 453d | 50d |
| 53 | 1.10.4 | 4.0 Complete SSEA Form or SEA Report | 5d | 2022-12-22 | 2022-12-28 | 50, 51, 52 | 423d |  |
| 54 | 1.11 | **0ST1 Develop Structures Recommendations** | 25d | 2022-12-08 | 2023-01-11 |  | 403d |  |
| 55 | 1.11.1 | 1.0 Recommend Structure Type for the Concept Report | 10d | 2022-12-08 | 2022-12-21 | 12 | 403d | 26d |
| 56 | 1.11.2 | 2.0 Provide Hydraulic Recommendations for the Concept Report | 10d | 2022-12-08 | 2022-12-21 | 12 | 403d | 26d |
| 57 | 1.11.3 | 3.0 Attend Site Visit | 1d | 2023-01-11 | 2023-01-11 | 14FF | 413d |  |

| ID | WBS | Task | Duration | Start | Finish | Predecessors | Total slack | Free slack | Constraint |
| --- | --- | --- | --- | --- | --- | --- | --- | --- | --- |
| 58 | 1.12 | **0UT1 Complete Utility Preliminary Estimates** | 10d | 2023-01-20 | 2023-02-02 |  | 383d |  |  |
| 59 | 1.12.1 | 1.0 Prepare Preliminary Utility Estimate | 10d | 2023-01-20 | 2023-02-02 | 16, 12 | 383d | 6d |  |
| 60 | 1.12.2 | 2.0 Prepare Preliminary Railroad Cost Estimate | 10d | 2023-01-20 | 2023-02-02 | 12, 16 | 383d | 6d |  |
| 61 | 2 | **STAGE 1- CONTEXT/SCOPING** | 253d? | 2022-09-23 | 2023-09-25 |  | 0d |  |  |
| 62 | 2.1 | **1PM1 Set Up Project** | 16d | 2022-09-23 | 2022-10-14 |  | 0d |  |  |
| 63 | 2.1.1 | 1.0 Confirm Project Assignment | 1d | 2022-09-23 | 2022-09-23 |  | 0d |  | start no earlier than 2022-09-23 |
| 64 | 2.1.2 | 2.0 Request Shared Project Folder | 5d | 2022-09-26 | 2022-09-30 | 63 | 473d |  |  |
| 65 | 2.1.3 | 3.0 Prepare Draft Project Scope | 10d | 2022-09-26 | 2022-10-07 | 63 | 468d |  |  |
| 66 | 2.1.4 | 4.0 Prepare Preliminary Schedule | 15d | 2022-09-26 | 2022-10-14 | 63 | 463d | 32d |  |
| 67 | 2.1.5 | **5.0 Validate Preliminary Budget** | 10d | 2022-09-26 | 2022-10-07 | 63 | 468d |  |  |
| 68 | 2.1.5.1 | - Confirm/Coordinate Approval of Project in the STIP/TIP | 10d | 2022-09-26 | 2022-10-07 | 63 | 468d |  |  |
| 69 | 2.1.6 | 6.0 Prepare Draft Quality Management Plan | 15d | 2022-09-26 | 2022-10-14 | 63 | 463d |  |  |
| 70 | 2.1.7 | 7.0 Prepare Draft Risk Management Plan | 10d | 2022-09-26 | 2022-10-07 | 63 | 468d |  |  |
| 71 | 2.1.8 | 8.0 Prepare Draft Project Communication Plan | 10d | 2022-09-26 | 2022-10-07 | 63 | 468d |  |  |
| 72 | 2.1.9 | 9.0 Prepare Draft Project Commitment Document (PCD) | 10d | 2022-09-26 | 2022-10-07 | 63 | 468d |  |  |
| 73 | 2.1.10 | 10.0 Request and Obtain Authorization of Funds (PE-N and Incidentals) | 10d | 2022-09-26 | 2022-10-07 | 63 | 468d |  |  |
| 74 | 2.2 | **1PM2 Build Project Team** | 25d | 2022-09-26 | 2022-10-28 |  | 0d |  |  |
| 75 | 2.2.1 | 1.0 Identify Project Team Resources | 5d | 2022-09-26 | 2022-09-30 | 63 | 0d |  |  |
| 76 | 2.2.2 | 2.0 Build Project Team | 20d | 2022-10-03 | 2022-10-28 | 75 | 0d |  |  |
| 77 | 2.2.3 | 3.0 Determine Type of Consultant(s) and Contract(s) Required | 2d | 2022-09-26 | 2022-09-27 | 63 | 3d | 0d |  |
| 78 | 2.2.4 | 4.0 Obtain Consultant(s) | 20d | 2022-09-28 | 2022-10-25 | 77 | 3d | 0d |  |
| 79 | 2.3 | **1PM3 Hold Kickoff Meeting** | 26d | 2022-09-26 | 2022-10-31 |  | 25d |  |  |
| 80 | 2.3.1 | 1.0 Set Up Meeting and Develop Agenda | 5d | 2022-09-26 | 2022-09-30 | 63 | 483d |  |  |
| 81 | 2.3.2 | 2.0 Hold Meeting and Document/Distribute Minutes | 1d | 2022-10-31 | 2022-10-31 | 76, 78 | 0d |  |  |
| 82 | 2.3.3 | 3.0 Verify the ETSA | 1d | 2022-10-31 | 2022-10-31 | 76, 78 | 462d |  |  |

Notes:
- 73: To include PE-N and ROW/Utility Incidentals, if not already authorized
- 82: As needed and could be done at the kickoff meeting

| ID | WBS | Task | Duration | Start | Finish | Predecessors | Total slack | Free slack |
| --- | --- | --- | --- | --- | --- | --- | --- | --- |
| 83 | 2.4 | **1PM4 Conduct Initial Risk Workshop** | 252d | 2022-09-26 | 2023-09-25 |  | 236d |  |
| 84 | 2.4.1 | 1.0 Set Up Meeting and Develop Agenda | 1d | 2022-09-26 | 2022-09-26 | 63 | 487d |  |
| 85 | 2.4.2 | 2.0 Hold Meeting and Document/Distribute Minutes | 1d | 2022-10-31 | 2022-10-31 | 76, 78 | 462d |  |
| 86 | 2.4.3 | **3.0 Update and Monitor Risk Register** | 205d | 2022-12-05 | 2023-09-25 |  | 236d |  |
| 87 | 2.4.3.1 | - Initial Risk Register | 1d | 2022-12-05 | 2022-12-05 | 128FS+5d | 440d |  |
| 88 | 2.4.3.2 | - Risk Update #1 | 1d | 2023-05-17 | 2023-05-17 | 256FS+5d | 326d |  |
| 89 | 2.4.3.3 | - Risk Update #2 | 1d | 2023-09-25 | 2023-09-25 | 309FS+5d | 236d |  |
| 90 | 2.5 | **1SY1 Conduct Design-Level Survey** | 56d? | 2022-09-26 | 2022-12-15 |  | 74d |  |
| 91 | 2.5.1 | 1.0 Prepare the Ground Control for Aerial Survey | 10d | 2022-09-26 | 2022-10-07 |  | 453d | 0d |
| 92 | 2.5.2 | 2.0 Complete the Aerial Survey | 25d | 2022-10-10 | 2022-11-14 | 91 | 453d |  |
| 93 | 2.5.3 | 3.0 Set Control Ground Survey | 5d | 2022-09-26 | 2022-09-30 | 63 | 74d | 0d |
| 94 | 2.5.4 | 4.0 Conduct Survey Public Involvement and Ground Survey | 1d? | 2022-10-03 | 2022-10-03 | 93 | 74d | 20d |
| 95 | 2.5.5 | 5.0 Incorporate SUE Request into Survey | 10d | 2022-12-02 | 2022-12-15 | 99SS-20d, 102SS+20d | 432d |  |
| 96 | 2.6 | **1RD1 Initiate Roadway Design** | 10d? | 2022-11-01 | 2022-11-15 |  | 34d |  |
| 97 | 2.6.1 | 1.0 Establish Project-Specific Design Criteria | 10d | 2022-11-01 | 2022-11-15 | 81 | 452d |  |
| 98 | 2.6.2 | 2.0 Determine Work Zone Significance | 10d | 2022-11-01 | 2022-11-15 | 81 | 452d |  |
| 99 | 2.6.3 | 3.0 Develop Line, Grade, and Cross Sections (Line and Grade Package) | 1d? | 2022-11-01 | 2022-11-01 | 81, 94FS-1mo | 34d | 0d |
| 100 | 2.6.4 | 4.0 Compile the Line and Grade Package for Field Review | 5d | 2022-11-02 | 2022-11-08 | 99 | 34d | 0d |
| 101 | 2.7 | **1UT1 Begin Third-Party (Utilities & Railroad) Coordination** | 51d | 2022-11-01 | 2023-01-13 |  | 351d | 0d |
| 102 | 2.7.1 | 1.0 Make Initial Utility Contact | 50d | 2022-11-01 | 2023-01-12 | 81 | 351d | 0d |
| 103 | 2.7.2 | 2.0 Conduct Utility Coordination Kickoff Meeting | 1d | 2023-01-13 | 2023-01-13 | 102 | 351d | 0d |
| 104 | 2.7.3 | 3.0 Initiate Railroad Coordination | 20d | 2022-11-01 | 2022-12-01 | 81 | 442d |  |
| 105 | 2.8 | **1EN1 Complete Environmental Resource Identification** | 40d | 2022-11-01 | 2022-12-29 |  | 0d |  |
| 106 | 2.8.1 | 1.0 Identify Historic Property Boundary(ies) and Initiate Agency Coordination | 40d | 2022-11-01 | 2022-12-29 | 81 | 296d | 0d |
| 107 | 2.8.2 | 2.0 Identify Boundary(ies) for Potentially Eligible Archaeology Sites and Initiate Agency Coordination | 40d | 2022-11-01 | 2022-12-29 | 81 | 177d | 0d |
| 108 | 2.8.3 | 3.0 Conduct Native American Coordination to Identify Consulting Parties | 20d | 2022-11-01 | 2022-12-01 | 81 | 442d |  |

Notes:
- 84: Could be held with the kickoff meeting (logic assumes that right now; adjust as needed).
- 85: Could be held with the kickoff meeting (logic assumes that right now; adjust as needed).
- 91: Tie up to when it is best done seasonally
- 94: To included picking up utilities, property information, and potentially staked ecology features (OHWM, steams, ephemerals, wetlands) amongst other standard survey items.
- 95: Potential early task
- 99: Duration depends on size of the project/complexity of design, and can be run parallel with survey, but team will likely need at least a month to tie in survey.

| ID | WBS | Task | Duration | Start | Finish | Predecessors | Baseline start | Baseline finish | Baseline duration | Total slack | Free slack | Text1 |
| --- | --- | --- | --- | --- | --- | --- | --- | --- | --- | --- | --- | --- |
| 109 | 2.8.4 | **4.0 Identify Ecology Site Boundaries** | 40d | 2022-11-01 | 2022-12-29 |  |  |  |  | 0d |  |  |
| 110 | 2.8.4.1 | - Develop and send shapefiles of features to design | 20d | 2022-11-01 | 2022-12-01 | 81 |  |  |  | 20d |  |  |
| 111 | 2.8.4.2 | - Complete an Environmental Boundaries Report (EBR) | 40d | 2022-11-01 | 2022-12-29 | 81 |  |  |  | 0d |  |  |
| 112 | 2.8.5 | 5.0 Establish Air Quality Designation | 40d | 2022-11-01 | 2022-12-29 | 81 |  |  |  | 296d | 0d |  |
| 113 | 2.8.6 | 6.0 Identify Potential Noise Receptor Locations | 40d | 2022-11-01 | 2022-12-29 | 81 |  |  |  | 147d | 0d |  |
| 114 | 2.8.7 | 7.0 Identify Potential Hazardous Materials Sites | 40d | 2022-11-01 | 2022-12-29 | 81 |  |  |  | 296d | 0d |  |
| 115 | 2.8.8 | 8.0 Identify Section 4(f) and Section 6(f) Resources | 40d | 2022-11-01 | 2022-12-29 | 81 |  |  |  | 422d |  |  |
| 116 | 2.9 | **1GT1 Develop Geotechnical Work Plan** | 30d | 2022-11-01 | 2022-12-15 |  |  |  |  | 432d |  |  |
| 117 | 2.9.1 | 1.0 Gather Relevant Geotechnical Information | 5d | 2022-11-01 | 2022-11-07 | 81 |  |  |  | 447d | 0d |  |
| 118 | 2.9.2 | 2.0 Complete Project-Specific Geotechnical Investigation | 10d | 2022-11-08 | 2022-11-22 | 117 |  |  |  | 447d |  |  |
| 119 | 2.9.3 | 3.0 Identify Project Type and Potential Mitigation Strategies | 5d | 2022-11-23 | 2022-12-01 | 118 |  |  |  | 432d | 0d |  |
| 120 | 2.9.4 | 4.0 Develop Geotechnical Work Plan | 10d | 2022-12-02 | 2022-12-15 | 117, 100, 119 |  |  |  | 432d |  |  |
| 121 | 2.10 | **1ST1 Complete Existing and No Structure Modeling** | 20d | 2022-11-01 | 2022-12-01 |  |  |  |  | 442d |  |  |
| 122 | 2.10.1 | 1.0 Hydraulically Model Existing and No Structure Conditions | 20d | 2022-11-01 | 2022-12-01 | 81, 94 |  |  |  | 442d |  |  |
| 123 | 2.11 | **1TO1 Validate Analysis and Determine Significance** | 10d? | 2022-11-01 | 2022-11-15 |  |  |  |  | 452d |  |  |
| 124 | 2.11.1 | 1.0 Validate Traffic Analysis | 1d? | 2022-11-01 | 2022-11-01 | 81 |  |  |  | 461d |  |  |
| 125 | 2.11.2 | 2.0 Determine Work Zone Significance | 10d | 2022-11-01 | 2022-11-15 | 81 |  |  |  | 452d |  |  |
| 126 | 2.12 | **1PM5 Hold Scoping Meeting and Site Review** | 65d | 2022-10-26 | 2023-01-30 |  |  |  |  | 401d |  |  |
| 127 | 2.12.1 | 1.0 Set Up Meeting and Develop Agenda | 1d | 2022-10-26 | 2022-10-26 | 128SS-10d |  |  |  | 465d |  |  |
| 128 | 2.12.2 | 2.0 Review and Complete Comment Form | 10d | 2022-11-09 | 2022-11-23 | 100 |  |  |  | 416d | 0d |  |
| 129 | 2.12.3 | 3.0 Compile Comments, Hold Meeting, and Document/Distribute Minutes | 5d | 2022-11-28 | 2022-12-02 | 128 | 2022-07-07 | 2022-07-20 | 10d | 416d | 0d | Yes |
| 130 | 2.12.4 | 4.0 Estimate the Project Using the Line and Grade Package | 10d | 2023-01-17 | 2023-01-30 | 100, 52, 101 |  |  |  | 376d | 0d |  |
| 131 | 2.12.5 | 5.0 Determine Need for Value Engineering | 5d | 2022-11-28 | 2022-12-02 | 128 |  |  |  | 431d | 0d |  |
| 132 | 3 | **STAGE 2- FOOTPRINT ESTABLISHED** | 281d? | 2022-09-26 | 2023-11-03 |  |  |  |  | 66d |  |  |
| 133 | 3.1 | **2PM1 Manage Project** | 281d? | 2022-09-26 | 2023-11-03 |  |  |  |  | 207d |  |  |
| 134 | 3.1.1 | **1.0 Develop Project Management Plan** | 97d | 2022-10-17 | 2023-03-07 |  |  |  |  | 376d |  |  |
| 135 | 3.1.1.1 | - PMP Update 1 | 10d | 2022-10-17 | 2022-10-28 | 62 |  |  |  | 463d |  |  |
| 136 | 3.1.1.2 | - PMP Update 2 | 5d | 2023-03-01 | 2023-03-07 | 152 |  |  |  | 376d |  |  |

Notes:
- 109: It is recommended that the data collection/field survey work for ecology be done as soon as possible in Stage 1 (and while survey is modelized in 1SY1), so that the shapefiles can be incorporated into the Line and Grade Package before finalizing. If the shapefiles will be available prior to the EBR, tie all associated schedule logic to the subtask, "Develop and send shapefiles of features to design."
- 126: This could serve as the Line and Grade review, if a more formal meeting is not added into the schedule.
- 129: Confirm scope, schedule, budget
- 134: This activity also covers 3PM1 and 4PM1

| ID | WBS | Task | Duration | Start | Finish | Predecessors | Total slack | Free slack |
| --- | --- | --- | --- | --- | --- | --- | --- | --- |
| 137 | 3.1.2 | **2.0 Report Project Status** | 97d | 2022-10-17 | 2023-03-07 |  | 376d |  |
| 138 | 3.1.2.1 | - Status Update 1 | 5d | 2022-10-17 | 2022-10-21 | 62 | 468d |  |
| 139 | 3.1.2.2 | - Status Update 2 | 5d | 2023-03-01 | 2023-03-07 | 152 | 376d |  |
| 140 | 3.1.3 | **3.0 Finalize Local Government Agreements** | 80d | 2022-09-26 | 2023-01-19 |  | 353d |  |
| 141 | 3.1.3.1 | - Enter Agreement 1 Name | 80d | 2022-09-26 | 2023-01-19 | 63 | 353d |  |
| 142 | 3.1.3.2 | - Enter Agreement 2 Name | 20d | 2022-09-26 | 2022-10-21 |  | 413d |  |
| 143 | 3.1.4 | 4.0 Perform Letting Readiness Assessment | 5d | 2022-09-26 | 2022-09-30 |  | 483d |  |
| 144 | 3.1.5 | - Functional Design Plans | 5d | 2023-04-26 | 2023-05-02 | 171 | 337d |  |
| 145 | 3.1.6 | - Plan-in-Hand | 5d | 2023-09-01 | 2023-09-08 | 263 | 247d |  |
| 146 | 3.1.7 | - Construction Documents | 5d | 2023-10-30 | 2023-11-03 | 314 | 207d |  |
| 147 | 3.1.8 | 5.0 Support Value Engineering Efforts | 10d | 2022-12-05 | 2022-12-16 | 131, 129 | 431d |  |
| 148 | 3.1.9 | 6.0 Manage Consultant Contracts and Modifications | 1d? | 2022-10-26 | 2022-10-26 | 63, 78 | 465d |  |
| 149 | 3.2 | **2PM2 Complete Project Commitment Document (PCD)** | 60d | 2022-12-05 | 2023-02-28 |  | 381d |  |
| 150 | 3.2.1 | 1.0 Verify Schedule | 10d | 2022-12-05 | 2022-12-16 | 66, 129 | 431d |  |
| 151 | 3.2.2 | 2.0 Verify Estimates | 10d | 2023-01-31 | 2023-02-13 | 129, 195, 194, 181, 130 | 376d | 0d |
| 152 | 3.2.3 | 3.0 Finalize Project Commitment Document (PCD) | 10d | 2023-02-14 | 2023-02-28 | 151 | 376d | 0d |
| 153 | 3.3 | **2SY1 Complete SUE and Requested Staking** | 117d | 2022-09-26 | 2023-03-14 |  | 371d |  |
| 154 | 3.3.1 | 1.0 Incorporate SUE Level A and B Request into Survey | 20d | 2023-02-14 | 2023-03-14 | 193, 158 | 351d | 0d |
| 155 | 3.3.2 | 2.0 Stake Sounding Holes | 15d | 2022-09-26 | 2022-10-14 |  | 473d |  |
| 156 | 3.4 | **2RD1 Develop Functional Design Plans** | 176d? | 2022-09-26 | 2023-06-07 |  | 120d |  |
| 157 | 3.4.1 | 1.0 Develop a Utility Impact/Conflict Matrix | 10d | 2023-01-17 | 2023-01-30 | 103, 99 | 351d | 0d |
| 158 | 3.4.2 | 2.0 Identify Initial Subsurface Utility Engineering (SUE) Needs | 15d | 2022-11-09 | 2022-12-02 | 100 | 391d | 40d |
| 159 | 3.4.3 | **3.0 Request Pavement Design** | 53d | 2022-09-26 | 2022-12-12 |  | 120d |  |
| 160 | 3.4.3.1 | - Request initial pavement design | 1d | 2022-11-09 | 2022-11-09 | 100 | 88d | 0d |
| 161 | 3.4.3.2 | - Receive and incorporate draft pavement design | 10d | 2022-11-29 | 2022-12-12 | 178 | 88d |  |
| 162 | 3.4.3.3 | - Request final pavement design | 1d | 2022-09-26 | 2022-09-26 |  | 457d | 0d |
| 163 | 3.4.3.4 | - Receive and incorporate final pavement design | 20d | 2022-10-11 | 2022-11-07 | 179 | 457d |  |
| 164 | 3.4.4 | 4.0 Document Design Exceptions and Waivers | 10d | 2022-11-09 | 2022-11-23 | 100 | 98d | 0d |
| 165 | 3.4.5 | 5.0 Incorporate SUE Data and Lead Internal Design Deconfliction Meeting | 10d | 2023-03-15 | 2023-03-28 | 154 | 361d |  |
| 166 | 3.4.6 | 6.0 Develop Utility Coordination Plans | 30d | 2022-11-09 | 2022-12-23 | 100 | 205d | 0d |
| 167 | 3.4.7 | 7.0 Develop Design and Sketches for Permit Applications | 30d | 2023-01-23 | 2023-03-06 | 109, 100, 236 | 270d | 0d |
| 168 | 3.4.8 | 8.0 Develop Conceptual Traffic Control Strategies | 15d | 2022-11-09 | 2022-12-02 | 100 | 94d | 0d |
| 169 | 3.4.9 | 9.0 Develop the Functional Design Plans | 1d? | 2022-11-28 | 2022-11-28 | 164 | 98d |  |
| 170 | 3.4.10 | 10.0 Coordinate Geotechnical Analysis for Noise and Retaining Walls | 5d | 2022-11-09 | 2022-11-16 | 100 | 201d | 0d |
| 171 | 3.4.11 | 11.0 Compile the Functional Design Plans and Participate in the Field Review | 5d | 2023-04-18 | 2023-04-25 | 252, 202, 228, 248, 250, 251, 168, 169, 176, 215, 214, 218, 161 | 0d |  |
| 172 | 3.4.12 | 12.0 Revise and Submit Updated Functional Design Plans | 15d | 2023-05-17 | 2023-06-07 | 257 | 312d |  |

Notes:
- 141: Check duration and logic for each project
- 142: Need to tie up if additional agreements are needed
- 157: Or use related line under 2UT1
- 162: Tie up based on plan set refinement either prior to Functional Design Plans or in Stage 3 for the Plan-in-Hand Plans
- 166: This could begin in Stage 2 or early Stage 3. Consider advancing at risk if the project is under an accelerated schedule.
- 167: This could begin in Stage 2 or early Stage 3. Consider advancing at risk if the project is under an accelerated schedule.

| ID | WBS | Task | Duration | Start | Finish | Predecessors | Total slack | Free slack |
| --- | --- | --- | --- | --- | --- | --- | --- | --- |
| 173 | 3.5 | **2RD2 Conduct Design Public Meeting** | 56d | 2022-11-09 | 2023-01-31 |  | 53d |  |
| 174 | 3.5.1 | 1.0 Prepare for the Design Public Meeting | 45d | 2022-11-09 | 2023-01-13 | 100 | 53d | 0d |
| 175 | 3.5.2 | 2.0 Hold Design Public Meeting | 1d | 2023-01-17 | 2023-01-17 | 174 | 53d | 0d |
| 176 | 3.5.3 | 3.0 Process Design Public Meeting Transcript | 10d | 2023-01-18 | 2023-01-31 | 175 | 53d |  |
| 177 | 3.6 | **2PV1 Provide Pavement Design** | 42d | 2022-09-27 | 2022-11-28 |  | 120d |  |
| 178 | 3.6.1 | 1.0 Provide Draft Pavement Design | 10d | 2022-11-10 | 2022-11-28 | 160 | 88d | 0d |
| 179 | 3.6.2 | 2.0 Provide Final Pavement Design | 10d | 2022-09-27 | 2022-10-10 | 162 | 457d | 0d |
| 180 | 3.7 | **2RW1 Initiate Pre-Acquisition Activities** | 25d | 2022-11-09 | 2022-12-16 |  | 280d |  |
| 181 | 3.7.1 | 1.0 Prepare Right-of-Way Estimate | 10d | 2022-11-09 | 2022-11-23 | 100 | 421d | 5d |
| 182 | 3.7.2 | 2.0 Perform Title Searches | 15d | 2022-11-09 | 2022-12-02 | 100 | 280d | 0d |
| 183 | 3.7.3 | 3.0 Initiate Private Property Owner Utility Adjustment | 15d | 2022-11-09 | 2022-12-02 | 100 | 290d | 10d |
| 184 | 3.7.4 | 4.0 Initiate PGI Field Work | 10d | 2022-12-05 | 2022-12-16 | 182 | 280d | 0d |
| 185 | 3.8 | **2PM3 Conduct ROW Strategy Meeting(s)** | 72d? | 2022-09-26 | 2023-01-06 |  | 416d |  |
| 186 | 3.8.1 | 1.0 Set Up Meeting and Develop Agenda | 1d | 2022-11-02 | 2022-11-02 | 99 | 420d | 4d |
| 187 | 3.8.2 | 2.0 Hold Meeting and Document/Distribute Minutes | 40d | 2022-11-09 | 2023-01-06 | 186, 100 | 416d |  |
| 188 | 3.8.3 | 3.0 Attend ROW Site Visit and Collect Feedback | 1d? | 2022-09-26 | 2022-09-26 |  | 487d |  |
| 189 | 3.9 | **2RW2 Execute ROW Proposal** | 2d? | 2022-11-09 | 2022-11-10 |  | 399d |  |
| 190 | 3.9.1 | 1.0 Prepare/Submit ROW Proposal | 1d? | 2022-11-09 | 2022-11-09 | 100 | 399d | 0d |
| 191 | 3.9.2 | 2.0 Receive ROW Proposal and Distribute for Execution | 1d? | 2022-11-10 | 2022-11-10 | 190 | 399d |  |
| 192 | 3.10 | **2UT1 Utility/Railroad Pre-Acquisition Activities** | 105d | 2022-11-09 | 2023-04-11 |  | 351d |  |
| 193 | 3.10.1 | 1.0 Coordinate/Request Needed SUE | 10d | 2023-01-31 | 2023-02-13 | 157, 158 | 351d | 0d |
| 194 | 3.10.2 | 2.0 Prepare Utility Estimate | 10d | 2022-11-09 | 2022-11-23 | 100 | 421d | 5d |
| 195 | 3.10.3 | 3.0 Prepare Railroad Estimates | 10d | 2022-11-09 | 2022-11-23 | 100 | 421d | 5d |
| 196 | 3.10.4 | 4.0 Develop a Utility Impact/Conflict Matrix | 10d | 2023-01-17 | 2023-01-30 | 103, 100 | 401d |  |
| 197 | 3.10.5 | 5.0 Review SUE Data and Attend Internal Design Deconfliction Meeting | 20d | 2023-03-15 | 2023-04-11 | 154 | 351d |  |

Notes:
- 174: Public meeting requests need to be submitted 8 weeks before the public meeting to CRD
- 182: Duration will depend on number of acquisitions/relocations
- 184: Duration will depend on number of acquisitions/relocations
- 188: Various (as many as needed)
- 193: Coordinate with Line 70
- 196: Or use related line 69 under 2RD1

| ID | WBS | Task | Duration | Start | Finish | Predecessors | Total slack | Free slack |
| --- | --- | --- | --- | --- | --- | --- | --- | --- |
| 198 | 3.11 | **2GT1 Complete the Soils and Geology Report** | 107d? | 2022-09-26 | 2023-02-28 |  | 66d |  |
| 199 | 3.11.1 | 1.0 Conduct Site Exploration for Soils and Geology Report | 30d | 2022-11-09 | 2022-12-23 | 100 | 34d | 0d |
| 200 | 3.11.2 | 2.0 Select the Appropriate Laboratory Testing Program | 10d | 2022-11-09 | 2022-11-23 | 100 | 54d | 20d |
| 201 | 3.11.3 | 3.0 Develop the Soils and Geology Report | 30d | 2022-12-26 | 2023-02-06 | 199, 200 | 34d | 0d |
| 202 | 3.11.4 | 4.0 Develop Associated Geotechnical Sheet (G-Sheets) | 15d | 2023-02-07 | 2023-02-28 | 201 | 34d |  |
| 203 | 3.11.5 | 5.0 Develop Supporting Project Addenda | 1d? | 2022-09-26 | 2022-09-26 |  | 487d |  |
| 204 | 3.12 | **2GT2 Complete Foundation Reports** | 80d | 2022-11-17 | 2023-03-14 |  | 201d |  |
| 205 | 3.12.1 | 1.0 Conduct Site Exploration for Structures | 40d | 2022-11-17 | 2023-01-13 | 219, 170, 100 | 201d | 0d |
| 206 | 3.12.2 | 2.0 Complete and Submit Foundation Report for Retaining Wall(s) | 30d | 2023-01-17 | 2023-02-28 | 205 | 226d | 79d |
| 207 | 3.12.3 | 3.0 Complete and Submit Foundation Report for Noise Wall(s) | 20d | 2023-01-17 | 2023-02-13 | 205 | 236d | 89d |
| 208 | 3.12.4 | 4.0 Complete and Submit Standard Report for Signs, Lighting, Signals, ITS, and High-Mast Lighting | 20d | 2023-01-17 | 2023-02-13 | 205 | 251d | 49d |
| 209 | 3.12.5 | 5.0 Complete and Submit Foundation Report for Bridges | 40d | 2023-01-17 | 2023-03-14 | 205 | 201d | 29d |
| 210 | 3.13 | **2ST1 Complete Hydraulic Design** | 55d | 2022-11-09 | 2023-01-30 |  | 54d |  |
| 211 | 3.13.1 | 1.0 Verify Proposed Grade and Estimate Hydraulic Structure Sizes | 15d | 2022-11-09 | 2022-12-02 | 100 | 54d | 0d |
| 212 | 3.13.2 | 2.0 Develop Draft Hydraulic Layout | 20d | 2022-12-05 | 2022-12-30 | 211 | 54d | 0d |
| 213 | 3.13.3 | 3.0 Hydraulically Model Proposed Conditions, Evaluate Proposals, and Select Appropriate Structure | 20d | 2022-12-05 | 2022-12-30 | 211 | 54d | 0d |
| 214 | 3.13.4 | 4.0 Finalize Hydraulic Layout | 20d | 2023-01-02 | 2023-01-30 | 212, 213 | 54d |  |
| 215 | 3.13.5 | 5.0 Finalize Hydraulic Design Information | 20d | 2023-01-02 | 2023-01-30 | 212, 213 | 54d |  |
| 216 | 3.14 | **2ST2 Develop Preliminary Bridge Plans** | 55d | 2022-11-09 | 2023-01-30 |  | 54d |  |
| 217 | 3.14.1 | 1.0 Review Proposed Grade and Alignment for Non-Hydraulic Crossings | 15d | 2022-11-09 | 2022-12-02 | 100 | 54d | 0d |
| 218 | 3.14.2 | 2.0 Develop Preliminary Bridge Layouts | 40d | 2022-12-05 | 2023-01-30 | 217 | 54d |  |
| 219 | 3.14.3 | 3.0 Coordinate Geotechnical Analysis for Bridges | 5d | 2022-11-09 | 2022-11-16 | 100 | 201d | 0d |
| 220 | 3.15 | **2EN1 Complete Environmental Resource Effects/Impacts** | 154d? | 2022-11-09 | 2023-06-21 |  | 108d | 0d |
| 221 | 3.15.1 | 1.0 Complete Necessary Resource Effect/Impact Evaluations (all other resources) | 1d? | 2022-11-09 | 2022-11-09 | 100 | 330d |  |
| 222 | 3.15.2 | 2.0 Complete Historic Preservation Effects Study | 1d? | 2022-12-30 | 2022-12-30 | 106, 100 | 296d |  |
| 223 | 3.15.3 | 3.0 Complete Phase Two Archaeological Eligibility Study | 120d | 2022-12-30 | 2023-06-21 | 107, 100 | 177d |  |
| 224 | 3.15.4 | 4.0 Complete Air Quality Impact Study | 1d? | 2022-12-30 | 2022-12-30 | 112, 100 | 296d |  |
| 225 | 3.15.5 | 5.0 Complete Noise Abatement Study | 120d | 2022-12-30 | 2023-06-21 | 113, 100 | 147d | 0d |
| 226 | 3.15.6 | 6.0 Complete Ecology Environmental Boundaries Report | 1d? | 2022-12-30 | 2022-12-30 | 109, 100 | 296d |  |
| 227 | 3.15.7 | 7.0 Complete Hazardous Materials Study | 1d? | 2022-12-30 | 2022-12-30 | 114, 100 | 296d |  |
| 228 | 3.15.8 | 8.0 Confirm Multimodal Compliance Determination | 1d? | 2023-01-30 | 2023-01-30 | 44 | 54d |  |

Notes:
- 203: Tie up as needed
- 208: See PDN; this is likely going to just entail getting the borings and holding them for contractor reference; typically no formal report is needed for signal, signs, and lighting (with the exception of high-mast).
- 220: Depending on what resources are in the ETSA, the timelines/duration for a number of these studies could add considerable time to the schedule. What studies are required will not be known until the end of Stage 1/start of Stage 2. For this reason, it is advisable to not sign the PCD until the PM knows what studies are needed under 2EN1.

| ID | WBS | Task | Duration | Start | Finish | Predecessors | Total slack | Free slack | Text1 |
| --- | --- | --- | --- | --- | --- | --- | --- | --- | --- |
| 229 | 3.16 | **2EN2 Complete Environmental Document** | 220d | 2022-11-16 | 2023-09-29 |  | 177d |  |  |
| 230 | 3.16.1 | 1.0 Review/Finalize Purpose and Need Statement | 10d | 2022-11-16 | 2022-12-01 | 99SS+10d | 317d | 140d |  |
| 231 | 3.16.2 | 2.0 Complete Environmental Document | 20d | 2023-06-22 | 2023-07-20 | 220, 230 | 177d | 0d |  |
| 232 | 3.16.3 | 3.0 Receive Approval (as applicable) | 50d | 2023-07-21 | 2023-09-29 | 231 | 177d |  |  |
| 233 | 3.16.4 | 4.0 Functional Design Plans Review (if needed): Complete Environmental Document Re-Evaluation | 15d | 2023-04-26 | 2023-05-16 | 171 | 272d |  | Yes |
| 234 | 3.16.5 | 5.0 Plan-in-Hand Review: Complete Environmental Document Re-Evaluation | 20d | 2023-09-01 | 2023-09-29 | 263 | 177d |  | Yes |
| 235 | 3.17 | **2EN3 Conduct Permit Assessment** | 127d? | 2022-09-26 | 2023-03-28 |  | 255d | 19d |  |
| 236 | 3.17.1 | 1.0 Complete Permit Assessment | 15d | 2022-12-30 | 2023-01-20 | 109, 100 | 270d | 0d |  |
| 237 | 3.17.2 | 2.0 Finalize Plans and Sketch Review and Prepare Permittable Plans Package | 1d? | 2023-03-07 | 2023-03-07 | 236, 167 | 270d |  |  |
| 238 | 3.17.3 | 3.0 Evaluate Permittable Plans Package | 15d | 2023-03-08 | 2023-03-28 | 237 | 255d |  |  |
| 239 | 3.17.4 | 4.0 Lead Pre-application meeting with USACE and TDEC | 1d | 2022-09-26 | 2022-09-26 |  | 381d |  |  |
| 240 | 3.18 | **2PM4 Conduct Permit Strategy Meeting(s)** | 106d? | 2022-09-26 | 2023-02-27 |  | 382d |  |  |
| 241 | 3.18.1 | 1.0 Set Up Meeting and Develop Agenda | 1d? | 2022-12-30 | 2022-12-30 | 109 | 421d |  |  |
| 242 | 3.18.2 | 2.0 Hold Meeting and Document/Distribute Minutes | 40d | 2022-12-30 | 2023-02-27 | 109, 100 | 382d |  |  |
| 243 | 3.18.3 | 3.0 Verify Permit(s) Are Complete and Submitted | 1d? | 2022-09-26 | 2022-09-26 |  | 487d |  |  |
| 244 | 3.19 | **2EN4 Complete Mitigation Assessment and Initiate Mitigation Design** | 75d | 2022-12-30 | 2023-04-17 |  | 0d |  |  |
| 245 | 3.19.1 | **1.0 Complete Mitigation Assessment** | 35d | 2022-12-30 | 2023-02-17 |  | 0d |  |  |
| 246 | 3.19.1.1 | - Evaluate mitigation (Bank or In-Lieu fee) availability and permittee responsibilities | 20d | 2022-12-30 | 2023-01-27 | 109, 100 | 0d |  |  |
| 247 | 3.19.1.2 | - Identify Need for Concurrent Project | 15d | 2023-01-30 | 2023-02-17 | 246 | 0d |  |  |
| 248 | 3.19.2 | 2.0 Develop Preliminary Mitigation Plan (30% designed) | 40d | 2023-02-21 | 2023-04-17 | 245 | 0d |  |  |
| 249 | 3.20 | **2TO1 Prepare ITS, Signals, and Lighting Sheets** | 40d | 2022-11-09 | 2023-01-06 |  | 69d |  |  |
| 250 | 3.20.1 | 1.0 Prepare TSMO/ITS Device Sheets | 40d | 2022-11-09 | 2023-01-06 | 100 | 69d |  |  |
| 251 | 3.20.2 | 2.0 Prepare Signal Sheets | 40d | 2022-11-09 | 2023-01-06 | 100 | 69d |  |  |
| 252 | 3.20.3 | 3.0 Prepare Lighting Sheets | 40d | 2022-11-09 | 2023-01-06 | 100 | 69d |  |  |
| 253 | 3.20.4 | 4.0 Oversee Development of the Conceptual Traffic Control Strategies | 40d | 2022-11-09 | 2023-01-06 | 168SS | 416d |  |  |

Notes:
- 231: Includes sending FHWA Notice of Intent (if needed)
- 233: This could be 3 weeks to 6 months depending on impacts/changes in design. This activity is optional depending on if the environmental document is complete at the time the plans are submitted for review.
- 234: This could be 3 weeks to 6 months depending on impacts/changes in design.
- 237: Adjust duration based on complexity of permit impacts.
- 239: Optional task that will help in coordinating with USACE and TDEC on the project details and upcoming permit application and content.
- 243: Various (as many as needed)

| ID | WBS | Task | Duration | Start | Finish | Predecessors | Total slack | Free slack |
| --- | --- | --- | --- | --- | --- | --- | --- | --- |
| 254 | 3.21 | **2PM5 Hold Functional Design Plans Field Review Meeting** | 25d | 2023-04-11 | 2023-05-16 |  | 10d |  |
| 255 | 3.21.1 | 1.0 Set Up Meeting and Develop Agenda | 5d | 2023-04-11 | 2023-04-17 | 256SS-10d | 347d |  |
| 256 | 3.21.2 | 2.0 Review and Complete Comment Form | 10d | 2023-04-26 | 2023-05-09 | 171 | 0d |  |
| 257 | 3.21.3 | 3.0 Compile Comments, Hold Meeting, and Document/Distribute Minutes | 5d | 2023-05-10 | 2023-05-16 | 256 | 0d |  |
| 258 | 4 | **STAGE 3- PLAN-IN-HAND** | 433d? | 2022-09-26 | 2024-06-14 |  | 55d |  |
| 259 | 4.1 | **3RD1 Complete Plan-in-Hand Design** | 90d? | 2023-04-26 | 2023-08-31 |  | 15d |  |
| 260 | 4.1.1 | 1.0 Develop ROW Acquisition Exhibits | 30d | 2023-04-26 | 2023-06-07 | 171 | 201d | 0d |
| 261 | 4.1.2 | 2.0 Finalize the TMP & Complete the Temporary Traffic Control Plans | 1d? | 2023-04-26 | 2023-04-26 | 171 | 221d | 0d |
| 262 | 4.1.3 | 3.0 Complete Plan-in-Hand Plans | 1d? | 2023-05-17 | 2023-05-17 | 257 | 0d |  |
| 263 | 4.1.4 | 4.0 Compile the Plan-in-Hand Plans and Participate in the Field Review | 5d | 2023-08-25 | 2023-08-31 | 262, 261, 272, 280, 290, 291, 303, 304, 305, 306, 274 | 147d | 0d |
| 264 | 4.2 | **3UT1 Perform Utility Coordination** | 273d | 2022-09-26 | 2023-10-24 |  | 215d |  |
| 265 | 4.2.1 | 1.0 Process Consultant Requests | 5d | 2022-09-26 | 2022-09-30 |  | 483d |  |
| 266 | 4.2.2 | 2.0 Send Utility Coordination Plans | 5d | 2022-12-26 | 2022-12-30 | 166 | 205d | 0d |
| 267 | 4.2.3 | 3.0 Conduct Utility Plan Review Kickoff Meeting | 2d | 2023-01-02 | 2023-01-03 | 266 | 419d |  |
| 268 | 4.2.4 | 4.0 60-Day Deconfliction Meeting | 40d | 2023-01-02 | 2023-02-28 | 266 | 381d |  |
| 269 | 4.2.5 | 5.0 Complete 120-day Utility Review and Process Relocation Contract Requests | 86d | 2023-01-02 | 2023-05-04 | 266 | 205d | 0d |
| 270 | 4.2.6 | 6.0 Submit Rainbows to Environmental | 10d | 2023-05-05 | 2023-05-18 | 269 | 205d | 0d |
| 271 | 4.2.7 | 7.0 Put Utilities to Work | 120d | 2023-05-05 | 2023-10-24 | 269 | 215d |  |
| 272 | 4.2.8 | 8.0 Submit Construction Drawings to Design | 10d | 2023-05-19 | 2023-06-02 | 270 | 205d | 58d |
| 273 | 4.3 | **3UT2 Perform Railroad Coordination** | 1d? | 2023-05-18 | 2023-05-18 |  | 0d |  |
| 274 | 4.3.1 | 1.0 Receive Railroad Plans and Estimates | 1d? | 2023-05-18 | 2023-05-18 | 262 | 0d |  |
| 275 | 4.4 | **3UT3 Prepare and Submit Utility/Railroad Certification** | 280d | 2023-05-05 | 2024-06-14 |  | 0d |  |
| 276 | 4.4.1 | 1.0 Receive and Process Utility Deposits | 20d | 2023-05-05 | 2023-06-02 | 269 | 250d | 31d |
| 277 | 4.4.2 | 2.0 Verify Utility Coordination is Complete | 10d | 2023-07-19 | 2023-08-01 | 269, 270, 281, 276 | 219d |  |
| 278 | 4.4.3 | 3.0 Finalize Railroad Agreement(s) | 270d | 2023-05-19 | 2024-06-14 | 274 | 0d |  |

Notes:
- 254: 3 weeks (15 working days) is default timing broken down as follows: / 1) 2 weeks for TDOT reviewers to complete their review and submit a completed Comment Resolution Form / 2) One week for design team to compile comments and prepare for meeting. / 3) Field review meeting to occur at the end of the 3 weeks/15 working days.
- 260: This could begin in Stage 2 (later) or early Stage 3. Consider advancing at risk if the project is under an accelerated schedule.
- 262: Duration depends on size of the project/complexity of design, and can be run parallel with survey at risk.
- 273: Tied currently to Plan-in-Hand Plans, but could tie to Functional Design Plans if coordinated with Railroad
- 274: Duration needs to be coordinated with Railroad
- 278: Default duration that needs to be coordinated with Railroad

| ID | WBS | Task | Type | Duration | Start | Finish | Predecessors | Total slack | Free slack |
| --- | --- | --- | --- | --- | --- | --- | --- | --- | --- |
| 279 | 4.5 | **3EN1 Finalize Stream & Wetland Mitigation Design** |  | 30d | 2023-04-26 | 2023-06-07 |  | 202d |  |
| 280 | 4.5.1 | 1.0 Finalize Mitigation Plans |  | 30d | 2023-04-26 | 2023-06-07 | 244, 171 | 202d | 55d |
| 281 | 4.6 | **3EN2 Complete and Obtain Aquatic Permit** |  | 58d? | 2023-04-26 | 2023-07-18 |  | 219d | 0d |
| 282 | 4.6.1 | 1.0 Complete Aquatic Permit Application (for the roadway project) |  | 40d | 2023-04-26 | 2023-06-21 | 248, 235, 167, 220FF | 236d | 0d |
| 283 | 4.6.2 | 2.0 Obtain Aquatic Resource Permits |  | 1d? | 2023-06-22 | 2023-06-22 | 282 | 236d |  |
| 284 | 4.6.3 | 3.0 Modify or Complete Aquatic Permit Application (for Utility Relocation Impacts) |  | 40d | 2023-05-19 | 2023-07-17 | 270 | 219d | 0d |
| 285 | 4.6.4 | 4.0 Obtain Aquatic Resource Permits (for utilities) |  | 1d? | 2023-07-18 | 2023-07-18 | 284 | 219d |  |
| 286 | 4.7 | **3EN3 Complete and Obtain Stormwater Permit** |  | 70d | 2023-05-17 | 2023-08-24 |  | 202d |  |
| 287 | 4.7.1 | 1.0 Complete Stormwater Permit Application |  | 40d | 2023-05-17 | 2023-07-13 | 257 | 202d | 0d |
| 288 | 4.7.2 | 2.0 Obtain NPDES Coverage |  | 30d | 2023-07-14 | 2023-08-24 | 287 | 202d |  |
| 289 | 4.8 | **3ST1 Complete Structural Design** |  | 85d | 2023-04-26 | 2023-08-24 |  | 147d |  |
| 290 | 4.8.1 | 1.0 Complete Retaining/Noise Wall Sheets |  | 45d | 2023-06-22 | 2023-08-24 | 225, 207, 206, 171 | 147d | 0d |
| 291 | 4.8.2 | 2.0 Complete Design and Detail Bridge Plans and Estimate |  | 60d | 2023-04-26 | 2023-07-20 | 171, 209 | 172d | 25d |
| 292 | 4.9 | **3RW1 Complete Appraisal and Initiate Acquisition** |  | 140d? | 2022-12-19 | 2023-07-07 |  | 20d |  |
| 293 | 4.9.1 | 1.0 Produce Preliminary Group Inspection (PGI) Report |  | 20d | 2022-12-19 | 2023-01-13 | 183, 184 | 280d | 0d |
| 294 | 4.9.2 | 3.0 Employ Fee Appraiser |  | 20d | 2023-01-17 | 2023-02-13 | 293 | 280d | 79d |
| 295 | 4.9.3 | 4.0 Stake ROW | manual | 15d | 2023-01-17 | 2023-02-06 | 293 |  |  |
| 296 | 4.9.4 | 5.0 Appraise Property |  | 1d? | 2023-06-08 | 2023-06-08 | 294, 260 | 201d | 0d |
| 297 | 4.9.5 | 6.0 Review Appraisals |  | 1d? | 2023-07-07 | 2023-07-07 | 296SS+20d | 201d | 0d |
| 298 | 4.10 | **3RW2 Prepare and Submit ROW Certification** |  | 6d? | 2023-08-18 | 2023-08-25 |  | 201d |  |
| 299 | 4.10.1 | 1.0 Perform/Finish Acquiring Property |  | 1d? | 2023-08-18 | 2023-08-18 | 297SS+30d | 201d | 0d |
| 300 | 4.10.2 | 2.0 Perform/Finish ROW Relocation |  | 1d? | 2023-08-18 | 2023-08-18 | 297SS+30d | 201d | 0d |
| 301 | 4.10.3 | 3.0 Review ROW Acquisition Process, Verify/Update Schedule, and Issue ROW Certification |  | 5d | 2023-08-21 | 2023-08-25 | 299, 300 | 201d |  |
| 302 | 4.11 | **3TO1 Complete Signal, Lighting, and TSMO/ITS Device Design** |  | 30d | 2023-04-26 | 2023-06-07 |  | 202d |  |
| 303 | 4.11.1 | 1.0 Complete Signal Design |  | 30d | 2023-04-26 | 2023-06-07 | 171, 208 | 202d | 55d |
| 304 | 4.11.2 | 2.0 Complete Lighting Design |  | 30d | 2023-04-26 | 2023-06-07 | 171, 208 | 202d | 55d |
| 305 | 4.11.3 | 3.0 Complete TSMO/ITS Device Design |  | 30d | 2023-04-26 | 2023-06-07 | 171, 208 | 202d | 55d |
| 306 | 4.11.4 | 4.0 Review the TMP for Compliance |  | 10d | 2023-04-27 | 2023-05-10 | 261 | 221d | 74d |

Notes:
- 282: Confirm tie to certain
- 283: Duration based on permit type determined under 2EN2. This duration could be 120 days to 12 months depending on what permit is needed and if a off-site mitigation site is needed.
- 284: Note the tie to receiving response from utility owners regarding relocation of their facilities. This is a late tie, notably if the relocation is going to impact a feature. This tie may drive a lag in the schedule that can be mitigated with early utility coordination and a clear depiction of where the utility cannot go.
- 285: Work with Permitting on mitigating this risk, which could considerably extend the schedule depending on utility impacts to features. This risk can be mitigated with early coordination and working with utilities to understand where they can and cannot move.
- 287: As soon as the ESCPs are available
- 293: This can tie to Line and Grade if Line and Grade includes survey of the ROW.
- 296: Duration will depend on number of acquisitions/relocations
- 297: Duration will depend on number of acquisitions/relocations
- 299: Duration will depend on number of acquisitions/relocations
- 300: Duration will depend on number of acquisitions/relocations

| ID | WBS | Task | Type | Duration | Start | Finish | Predecessors | Total slack | Free slack |
| --- | --- | --- | --- | --- | --- | --- | --- | --- | --- |
| 307 | 4.12 | **3PM2 Hold Plan-in-Hand Field Review Meeting** |  | 25d | 2023-08-18 | 2023-09-22 |  | 157d |  |
| 308 | 4.12.1 | 1.0 Set Up Meeting and Develop Agenda |  | 5d | 2023-08-18 | 2023-08-24 | 309SS-10d | 257d |  |
| 309 | 4.12.2 | 2.0 Review and Complete Comment Form |  | 10d | 2023-09-01 | 2023-09-15 | 263 | 147d | 0d |
| 310 | 4.12.3 | 3.0 Compile Comments, Hold Meeting, and Document/Distribute Minutes |  | 5d | 2023-09-18 | 2023-09-22 | 309 | 147d | 0d |
| 311 | 5 | **STAGE 4- PS&E** |  | 35d | 2023-09-25 | 2023-11-13 |  | 147d |  |
| 312 | 5.1 | **4RD1 Finalize Construction Documents** |  | 25d | 2023-09-25 | 2023-10-27 |  | 147d |  |
| 313 | 5.1.1 | 1.0 Finalize the Roadway Plans for the PS&E Review Meeting |  | 15d | 2023-09-25 | 2023-10-13 | 310 | 147d | 0d |
| 314 | 5.1.2 | 2.0 Compile the Final Construction Documents |  | 10d | 2023-10-16 | 2023-10-27 | 313, 316, 317, 322, 323, 319, 320 | 147d | 0d |
| 315 | 5.2 | **4GT1 Finalize Geotech Plans** |  | 15d | 2023-09-25 | 2023-10-13 |  | 147d |  |
| 316 | 5.2.1 | 1.0 Finalize Geotechnical Design Documents |  | 15d | 2023-09-25 | 2023-10-13 | 310 | 147d | 0d |
| 317 | 5.2.2 | 2.0 Finalize Geotechnical Special Provisions for Letting |  | 15d | 2023-09-25 | 2023-10-13 | 310 | 147d | 0d |
| 318 | 5.3 | **4ST1 Finalize Structural Plans** |  | 15d | 2023-09-25 | 2023-10-13 |  | 147d |  |
| 319 | 5.3.1 | 1.0 Finalize Retaining/Noise Wall Plans |  | 15d | 2023-09-25 | 2023-10-13 | 310 | 147d | 0d |
| 320 | 5.3.2 | 2.0 Finalize Bridge Plans |  | 15d | 2023-09-25 | 2023-10-13 | 310 | 147d | 0d |
| 321 | 5.4 | **4TO1 Finalize Signal, Lighting, and TSMO/ITS Plans** |  | 15d | 2023-09-25 | 2023-10-13 |  | 147d |  |
| 322 | 5.4.1 | 1.0 Finalize Signals, Lighting, and TSMO/ITS Design Documents |  | 15d | 2023-09-25 | 2023-10-13 | 310 | 147d | 0d |
| 323 | 5.4.2 | 2.0 Finalize ITS Special Provisions |  | 15d | 2023-09-25 | 2023-10-13 | 310 | 147d | 0d |
| 324 | 5.5 | **4PM2 Hold PS&E Review Meeting** |  | 20d | 2023-10-16 | 2023-11-13 |  | 157d |  |
| 325 | 5.5.1 | 1.0 Set Up Meeting and Develop Agenda |  | 5d | 2023-10-16 | 2023-10-20 | 326SS-10d | 217d |  |
| 326 | 5.5.2 | 2.0 Review and Complete Comment Form |  | 5d | 2023-10-30 | 2023-11-03 | 314 | 147d | 0d |
| 327 | 5.5.3 | 3.0 Compile Comments, Hold Meeting, and Finalize Project Documentation |  | 5d | 2023-11-06 | 2023-11-13 | 326 | 147d |  |
| 328 | 6 | Construction Document Turn-in | milestone | 5d | 2024-06-17 | 2024-06-21 | 281, 229, 189, 277, 278, 301, 327, 234, 286, 140 | 0d |  |
| 329 | 7 | Project Letting | milestone | 50d | 2024-06-24 | 2024-09-03 | 328 | 0d |  |

Notes:
- 307: 3 weeks (15 working days) is default timing broken down as follows: / 1) 2 weeks for TDOT reviewers to complete their review and submit a completed Comment Resolution Form / 2) One week for design team to compile comments and prepare for meeting. / 3) Field review meeting to occur at the end of the 3 weeks/15 working days.
- 324: 2 weeks (10 working days) is default timing broken down as follows: / 1) 1 week for TDOT reviewers to complete their review and submit a completed Comment Resolution Form / 2) One week for design team to compile comments and prepare for meeting. / 3) Last review meeting to occur at the end of the 2 weeks/10 working days.
